# 03_SwissGroovesPlanung_Parallelisierung-AP_Bontekoe-Rohrer

Schedule from MS Project, 2014-04-01 to 2014-12-01.

## Calendars

- Standard: Mon-Fri 08:00-12:00, 13:00-17:00; Sat-Sun off.

## Resources

| Resource |
| --- |
| Blair Tony |
| Blocher Christoph |
| Berlusconi Silvio |
| Clay Cassius |
| Clinton Hillary |
| Lauda Niki |
| Obama Barak |
| Pelé |
| Putin Vladimir |
| Sarkozy Nicolas |
| Bush George |

## Schedule

| ID | WBS | Task | Type | Duration | Start | Finish | Predecessors | Total slack | Profile |
| --- | --- | --- | --- | --- | --- | --- | --- | --- | --- |
| 1 | 1 | Projektstart | milestone, manual | 0d | 2014-04-01 | 2014-04-01 |  |  |  |
| 2 | 2 | **SwissGrooves** |  | 175d | 2014-04-01 | 2014-12-01 | 1 | 0d |  |
| 3 | 2.1 | **R1 Applikationssoftware** |  | 135d | 2014-04-29 | 2014-11-03 |  | 0d |  |
| 4 | 2.1.1 | **R1.1 PoC** |  | 20d | 2014-04-29 | 2014-05-26 | 22 | 0d |  |
| 5 | 2.1.1.1 | POC-Model |  | 15d | 2014-04-29 | 2014-05-19 |  | 5d | DB-Architekt, SW-Architekt |
| 6 | 2.1.1.2 | POC-System |  | 20d | 2014-04-29 | 2014-05-26 |  | 0d | DB-Architekt, SW-Architekt |
| 7 | 2.1.1.3 | POC-CD |  | 15d | 2014-04-29 | 2014-05-19 |  | 5d | Marketing |
| 8 | 2.1.2 | **R1.2 AR1.0** |  | 75d | 2014-07-22 | 2014-11-03 |  | 0d |  |
| 9 | 2.1.2.1 | **R1.2.1 Basic** |  | 30d | 2014-07-22 | 2014-09-01 | 26 | 0d |  |
| 10 | 2.1.2.1.1 | App-Design |  | 30d | 2014-07-22 | 2014-09-01 |  | 0d | SW-Architekt |
| 11 | 2.1.2.1.2 | App-Spez |  | 25d | 2014-07-22 | 2014-08-25 |  | 5d | Requirement-Engineer |
| 12 | 2.1.2.1.3 | App-DB |  | 30d | 2014-07-22 | 2014-09-01 |  | 0d | DB-Architekt |
| 13 | 2.1.2.2 | **R1.2.2 Release** |  | 45d | 2014-09-02 | 2014-11-03 | 9, 26 | 0d |  |
| 14 | 2.1.2.2.1 | App-Content |  | 25d | 2014-09-02 | 2014-10-06 |  | 20d | Technischer Redaktor |
| 15 | 2.1.2.2.2 | App-Identity |  | 20d | 2014-09-02 | 2014-09-29 |  | 25d | SW-Entwickler |
| 16 | 2.1.2.2.3 | App-Social |  | 30d | 2014-09-02 | 2014-10-13 |  | 15d | SW-Entwickler |
| 17 | 2.1.2.2.4 | App-Cash |  | 45d | 2014-09-02 | 2014-11-03 |  | 0d | SW-Entwickler |
| 18 | 2.1.2.2.5 | App-Trace |  | 45d | 2014-09-02 | 2014-11-03 |  | 0d | SW-Entwickler |
| 19 | 2.1.2.2.6 | App-Feedback |  | 20d | 2014-09-02 | 2014-09-29 |  | 25d | SW-Entwickler |
| 20 | 2.2 | **R2 Applikationskonzept** |  | 155d | 2014-04-15 | 2014-11-17 | 1 | 0d |  |
| 21 | 2.2.1 | **R2.1 AK** |  | 70d | 2014-04-15 | 2014-07-21 |  | 0d |  |
| 22 | 2.2.1.1 | **R2.1.1 AK0.5** |  | 10d | 2014-04-15 | 2014-04-28 | 54, 58 | 0d |  |
| 23 | 2.2.1.1.1 | Prototyp-Model |  | 8d | 2014-04-15 | 2014-04-24 |  | 2d | DB-Architekt, SW-Architekt |
| 24 | 2.2.1.1.2 | Prototyp-System |  | 10d | 2014-04-15 | 2014-04-28 |  | 0d | System-Engineer, Network-Engineer |
| 25 | 2.2.1.1.3 | Prototyp-CD |  | 8d | 2014-04-15 | 2014-04-24 |  | 2d | Marketing |

Notes:
- 1: SwissGrooves
- 4: Proof of Concept
- 5: Prototyp: Kontext-Diagramm Informatiosnmodell Funktionsgliederung
- 6: System Design: Hardware / Software
- 7: Corporate Design / Benutzeroberfläche
- 8: Applikationsrelease 1.0
- 9: Basis-Release
- 10: Detailliertes Design Detaillierte Beschreibung der Benutzeroberfläche & Navigationsstruktur Usability Styleguide
- 11: Funktionale und nichtfunktionale Spezifikation Schnittstellenkonzept
- 12: Datenmodell
- 13: Release
- 14: Content-Management inkl. Aktualität (Produkt-Fotos etc.)
- 15: Identitiy-Management / Kundenlogin (Kunden-IDs)
- 16: Social-Features
- 17: Rabatt Optionen Zahlungs-Dienstleistung Inkasso-Dienstleistung
- 18: Auslieferung und Tracking Optionen
- 19: Feedback und Beschwerdemanagement
- 21: Applikationskonzept „SwissGrooves
- 22: Applikationskonzept „SwissGrooves für den Pilot/PoC
- 23: Prototyp: Kontext-Diagramm Informatiosnmodell Funktionsgliederung
- 24: System Design: Hardware / Software
- 25: Corporate Design / Benutzeroberfläche

| ID | WBS | Task | Duration | Start | Finish | Predecessors | Total slack | Profile |
| --- | --- | --- | --- | --- | --- | --- | --- | --- |
| 26 | 2.2.1.2 | **R2.1.2 AK-Spez** | 40d | 2014-05-27 | 2014-07-21 |  | 0d |  |
| 27 | 2.2.1.2.1 | **R2.1.2.1 Basic** | 15d | 2014-05-27 | 2014-06-16 | 4 | 0d |  |
| 28 | 2.2.1.2.1.1 | Concept-Design | 15d | 2014-05-27 | 2014-06-16 |  | 0d | Marketing |
| 29 | 2.2.1.2.1.2 | Concept-Spez | 12d | 2014-05-27 | 2014-06-11 |  | 3d | Requirement-Engineer |
| 30 | 2.2.1.2.1.3 | Concept-DB | 15d | 2014-05-27 | 2014-06-16 |  | 0d | DB-Architekt |
| 31 | 2.2.1.2.2 | **R2.1.2.2 Release** | 25d | 2014-06-17 | 2014-07-21 | 4, 27 | 0d |  |
| 32 | 2.2.1.2.2.1 | Concept-Content | 12d | 2014-06-17 | 2014-07-02 |  | 13d | Technischer Redaktor |
| 33 | 2.2.1.2.2.2 | Concept-Identity | 12d | 2014-06-17 | 2014-07-02 |  | 13d | Marketing |
| 34 | 2.2.1.2.2.3 | Concept-Social | 15d | 2014-06-17 | 2014-07-07 |  | 10d | SW-Entwickler |
| 35 | 2.2.1.2.2.4 | Concept-Cash | 25d | 2014-06-17 | 2014-07-21 |  | 0d | SW-Entwickler |
| 36 | 2.2.1.2.2.5 | Concept-Trace | 25d | 2014-06-17 | 2014-07-21 |  | 0d | SW-Entwickler |
| 37 | 2.2.1.2.2.6 | Concept-Feedback | 10d | 2014-06-17 | 2014-06-30 |  | 15d | SW-Entwickler |
| 38 | 2.2.2 | **R2.2 TK** | 125d | 2014-05-27 | 2014-11-17 |  | 10d |  |
| 39 | 2.2.2.1 | **R2.2.1 TK-PoC** | 10d | 2014-05-27 | 2014-06-09 | 4 | 125d |  |
| 40 | 2.2.2.1.1 | Testkonzept | 10d | 2014-05-27 | 2014-06-09 |  | 125d | Test-Engineer |
| 41 | 2.2.2.2 | **R2.2.2 TK-Complete** | 10d | 2014-11-04 | 2014-11-17 | 8 | 10d |  |
| 42 | 2.2.2.2.1 | TK-Complete | 10d | 2014-11-04 | 2014-11-17 |  | 10d | Test-Engineer |
| 43 | 2.2.3 | **R2.3 BHB** | 10d | 2014-11-04 | 2014-11-17 | 8 | 10d |  |
| 44 | 2.2.3.1 | BHB-Doc | 5d | 2014-11-04 | 2014-11-10 |  | 15d | Technischer Redaktor |
| 45 | 2.2.3.2 | BHB-Wiki | 5d | 2014-11-04 | 2014-11-10 |  | 15d | Technischer Redaktor |
| 46 | 2.2.3.3 | BHB-Online | 10d | 2014-11-04 | 2014-11-17 |  | 10d | Technischer Redaktor |
| 47 | 2.2.4 | **R2.4 OHB1.0** | 3d | 2014-11-04 | 2014-11-06 | 8 | 17d |  |
| 48 | 2.2.4.1 | OHB-Prozesse | 3d | 2014-11-04 | 2014-11-06 |  | 17d | Technischer Redaktor |
| 49 | 2.2.4.2 | OHB-Recovery | 2d | 2014-11-04 | 2014-11-05 |  | 18d | Technischer Redaktor |
| 50 | 2.2.4.3 | OHB-Naming | 1d | 2014-11-04 | 2014-11-04 |  | 19d | Technischer Redaktor |

Notes:
- 26: Applikationskonzept für „SwissGrooves Vers. 1.0 (definitive Fassung)
- 27: Basis-Concept
- 28: Detailliertes Design Detaillierte Beschreibung der Benutzeroberfläche & Navigationsstruktur Usability Styleguide
- 29: Funktionale und nichtfunktionale Spezifikation Schnittstellenkonzept
- 30: Datenmodell
- 31: Release
- 32: Content-Management inkl. Aktualität (Produkt-Fotos etc.)
- 33: Identitiy-Management / Kundenlogin (Kunden-IDs)
- 34: Social-Features
- 35: Rabatt Optionen Zahlungs-Dienstleistung Inkasso-Dienstleistung
- 36: Auslieferung und Tracking Optionen
- 37: Feedback und Beschwerdemanagement
- 38: Testkonzept
- 39: Testkonzept Vers. 0.5
- 40: Testfälle definieren
- 41: Testkonzept Vers 1.0 für Webshop Vers. 1.0
- 42: Vollständiges Testkonzept erstellen
- 43: Webshop Benutzer-Handbuch
- 44: Benutzerhandbuch in Dokumentenform
- 45: Wiki mit Hinweisen zur Benutzung des Systems
- 46: Online-Hilfe, vom Webshop aus zu erreichen
- 47: Webshop Betriebs-Handbuch
- 48: Wichtigsten IT Prozesse dokumentieren
- 49: Restart / Recovery Prozeduren dokumentieren
- 50: Naming-Konzept definieren

| ID | WBS | Task | Duration | Start | Finish | Predecessors | Total slack | Free slack | Profile |
| --- | --- | --- | --- | --- | --- | --- | --- | --- | --- |
| 51 | 2.3 | **R3 Business-Ergebnisse** | 15d | 2014-04-01 | 2014-04-21 | 1 | 0d |  |  |
| 52 | 2.3.1 | **R3.1 BC** | 5d | 2014-04-01 | 2014-04-07 |  | 0d |  |  |
| 53 | 2.3.1.1 | BC | 5d | 2014-04-01 | 2014-04-07 |  | 0d |  | Marketing |
| 54 | 2.3.2 | **R3.2 BO** | 5d | 2014-04-08 | 2014-04-14 | 53 | 0d |  |  |
| 55 | 2.3.2.1 | BO-Webshop | 5d | 2014-04-08 | 2014-04-14 |  | 0d |  | Prozess-Designer |
| 56 | 2.3.2.2 | BO-Schema | 5d | 2014-04-08 | 2014-04-14 |  | 0d |  | Marketing |
| 57 | 2.3.2.3 | BO-Strategie | 5d | 2014-04-08 | 2014-04-14 |  | 0d |  | Prozess-Designer |
| 58 | 2.3.3 | **R3.3 RG** | 5d | 2014-04-08 | 2014-04-14 | 53 | 0d |  |  |
| 59 | 2.3.3.1 | Recht-Feature | 5d | 2014-04-08 | 2014-04-14 |  | 0d |  | Rechtlicher-Berater |
| 60 | 2.3.3.2 | Recht-Usab | 5d | 2014-04-08 | 2014-04-14 |  | 0d |  | Rechtlicher-Berater |
| 61 | 2.3.3.3 | Recht-AGB | 5d | 2014-04-08 | 2014-04-14 |  | 0d |  | Rechtlicher-Berater |
| 62 | 2.3.4 | **R3.4 NP** | 5d | 2014-04-15 | 2014-04-21 | 54 | 160d |  |  |
| 63 | 2.3.4.1 | Produkt-Digital | 5d | 2014-04-15 | 2014-04-21 |  | 160d |  | Technischer Redaktor |
| 64 | 2.3.4.2 | Produkt-Hardware | 5d | 2014-04-15 | 2014-04-21 |  | 160d |  | Technischer Redaktor |
| 65 | 2.4 | **R4 Rollout** | 20d | 2014-11-04 | 2014-12-01 | 1 | 0d |  |  |
| 66 | 2.4.1 | **R4.1 RO** | 10d | 2014-11-04 | 2014-11-17 | 8 | 5d | 0d |  |
| 67 | 2.4.1.1 | Konzept-Rollout | 10d | 2014-11-04 | 2014-11-17 |  | 5d |  | Roll-Out-Engineer |
| 68 | 2.4.2 | **R4.2 MK** | 20d | 2014-11-04 | 2014-12-01 | 8 | 0d |  |  |
| 69 | 2.4.2.1 | Konzept-Marketing | 20d | 2014-11-04 | 2014-12-01 |  | 0d |  | Marketing |
| 70 | 2.4.3 | **R4.3 SK** | 5d | 2014-11-04 | 2014-11-10 | 8 | 12d |  |  |
| 71 | 2.4.3.1 | Konzept-Schulungs | 5d | 2014-11-04 | 2014-11-10 |  | 12d | 0d | Roll-Out-Engineer |
| 72 | 2.4.4 | **R4.4 SCH** | 3d | 2014-11-11 | 2014-11-13 | 71 | 12d |  |  |
| 73 | 2.4.4.1 | Schulung | 3d | 2014-11-11 | 2014-11-13 |  | 12d |  | Roll-Out-Engineer |
| 74 | 2.4.5 | **R4.5 BP** | 5d | 2014-11-18 | 2014-11-24 | 66 | 5d |  |  |
| 75 | 2.4.5.1 | Webshop-Befüllung | 5d | 2014-11-18 | 2014-11-24 |  | 5d |  | Technischer Redaktor |

Notes:
- 52: Business Case „SwissGrooves
- 53: Business Case (klassisch)
- 54: Geschäftsprozesse & -Modell/Strategie „SwissGrooves
- 55: Geschäftsprozesse für den Betrieb des Webshops
- 56: Graphische Darstellung der Produkt-, Service- Informations- und Geldflüsse sowie deren Akteure
- 57: Strategie basierend auf Geschäftsidee, Marktanalyse, Konkurrenzanalyse, Zielgruppen und Erfolgsfaktoren
- 58: Zahlungssystem & rechtliche Grundlagen
- 59: Evaluierung und Beurteilung der zu verwendenden Zahlungsmechanismen
- 60: Kundenfreundlichkeit (Zahlungsmethoden), Sicherheit der Zahlungsmethoden
- 61: AGB mit Jurist verifizieren / anpassen
- 62: Neue Produkte
- 63: Musikstücke zum Herunterladen
- 64: Produkte der Unterhaltungselektronik
- 66: Konzept Rollout SwissGrooves
- 67: Konzept für das Rollout des Webshops inkl. aller relevanten Schrite
- 68: Marketingkonzept
- 69: Marketingkonzept beschreibt Einführungsmassnahmen und Werbung
- 70: Schulungskonzept SwissGrooves
- 71: Schulungskonzept ausarbeiten für Endkunden und interne Mitarbeiter
- 72: Schulungsdurchführung
- 73: Schulungsdurchfühung in Bern und Basel
- 74: Befüllung Webshop
- 75: Befüllung Webshop

| ID | WBS | Task | Duration | Start | Finish | Predecessors | Total slack | Free slack | Profile |
| --- | --- | --- | --- | --- | --- | --- | --- | --- | --- |
| 76 | 2.5 | **R5 PM-Ergebnisse** | 42d | 2014-04-01 | 2014-05-28 | 1 | 133d |  |  |
| 77 | 2.5.1 | **R5.1 PA** | 5d | 2014-04-01 | 2014-04-07 |  | 170d |  |  |
| 78 | 2.5.1.1 | Projektantrag | 5d | 2014-04-01 | 2014-04-07 |  | 170d |  | Projektleiter |
| 79 | 2.5.2 | **R5.2 PP** | 12d | 2014-04-01 | 2014-04-16 |  | 163d |  |  |
| 80 | 2.5.2.1 | **R5.2.1 PP0.4** | 2d | 2014-04-01 | 2014-04-02 |  | 163d |  |  |
| 81 | 2.5.2.1.1 | PP01 | 2d | 2014-04-01 | 2014-04-02 |  | 163d | 0d | Projektleiter |
| 82 | 2.5.2.2 | **R5.2.2 PP0.7** | 4d | 2014-04-03 | 2014-04-08 | 81 | 163d |  |  |
| 83 | 2.5.2.2.1 | PP07 | 4d | 2014-04-03 | 2014-04-08 |  | 163d | 0d | Projektleiter |
| 84 | 2.5.2.3 | **R5.2.3 PP1.0** | 6d | 2014-04-09 | 2014-04-16 | 83 | 163d |  |  |
| 85 | 2.5.2.3.1 | PP10 | 6d | 2014-04-09 | 2014-04-16 |  | 163d |  | Projektleiter |
| 86 | 2.5.3 | **R5.3 RA** | 1d | 2014-05-27 | 2014-05-27 | 4 | 133d | 0d |  |
| 87 | 2.5.3.1 | RA | 1d | 2014-05-27 | 2014-05-27 |  | 133d |  | Risk-Manager |
| 88 | 2.5.4 | **R5.4 KP** | 1d | 2014-05-28 | 2014-05-28 | 86 | 133d |  |  |
| 89 | 2.5.4.1 | KP | 1d | 2014-05-28 | 2014-05-28 |  | 133d |  | Marketing |
| 90 | 2.5.5 | **R5.5 ST** | 10d | 2014-04-01 | 2014-04-14 |  | 165d |  |  |
| 91 | 2.5.5.1 | ST | 10d | 2014-04-01 | 2014-04-14 |  | 165d |  | Risk-Manager |

Notes:
- 77: Projektantrag
- 78: Projektantrag mit Ausgangszielen, Zielen, Scope und grober Projektplanung
- 79: Projektplan
- 80: Projektplan Version 0.4
- 81: Projektplan gemäss Ergebnisliste
- 82: Projektplan Version 0.7
- 83: Projektplan gemäss Ergebnisliste
- 84: Projektplan Version 1.0
- 85: Projektplan gemäss Ergebnisliste
- 86: Risikoanalyse
- 87: Risikoanalyse gemäss Ergebnisliste
- 88: Kommunikationsplan
- 89: Kommunikationsplan gemäss Ergebnisliste
- 90: Entscheidungsvorlage
- 91: Entscheidungsvorlage: Webshop mieten, Standardlösung kaufen oder OpenSource-Lösung anpassen?
